# Online Clothing

Schedule from MS Project, 2007-02-09 to 2007-06-28, costs in $.
UCSD

## Calendars

- Standard: Mon-Fri 08:00-12:00, 13:00-17:00; Sat-Sun off.

## Resources

| Resource | Rate |
| --- | --- |
| Project Manager | 50 |
| Analyst | 35 |
| Testing Group | 25 |
| Sales | 35 |
| DesignTeam | 35 |
| Engineering | 25 |
| IT Group | 35 |
| Marketing | 30 |
| Training | 30 |
| Technical Support | 40 |
| Legal Counsel | 75 |
| Contract Administrator | 50 |
| Controller | 75 |
| Houston | 40 |
| Jane | 40 |
| Jen | 40 |
| Lori | 40 |
| Tyler | 40 |
| Vendor Developers | 100 |
| Vendor Testers | 80 |

## Schedule

| ID | WBS | Task | Duration | Start | Finish | Predecessors | Total slack | Free slack | Resources | Work | Cost |
| --- | --- | --- | --- | --- | --- | --- | --- | --- | --- | --- | --- |
| 1 | 1 | **Online Clothing** | 99.5d | 2007-02-09 | 2007-06-28 |  | 0d |  |  | 1649h | 109,210 |
| 2 | 1.1 | **Project Management** | 26.5d | 2007-02-09 | 2007-03-19 |  | 0d |  |  | 207h | 8,510 |
| 3 | 1.1.1 | **Start Project** | 12.5d | 2007-02-09 | 2007-02-27 |  | 0d |  |  | 66h | 2,700 |
| 4 | 1.1.1.1 | Start website research | 5d | 2007-02-09 | 2007-02-15 |  | 0d |  | Houston [10%]; Jane [10%]; Jen [10%]; Lori [10%]; Tyler [10%] | 20h | 800 |
| 5 | 1.1.1.2 | Survey clothing store that recently implemented a website | 3d | 2007-02-16 | 2007-02-20 | 4 | 0d |  | Lori [25%]; Jen [25%] | 12h | 480 |
| 6 | 1.1.1.3 | Find industry average to design and build a merchant website | 2.5d | 2007-02-16 | 2007-02-20 | 4 | 0.5d |  | Jane [25%]; Tyler [25%] | 10h | 400 |
| 7 | 1.1.1.4 | Estimate the average time it will take to build our website | 1.5d | 2007-02-21 | 2007-02-22 | 5, 6 | 0d |  | Project Manager [25%]; Houston [25%] | 6h | 270 |
| 8 | 1.1.1.5 | Estimate cost to build our website | 1.5d | 2007-02-22 | 2007-02-23 | 7 | 0d |  | Project Manager [25%]; Lori [25%] | 6h | 270 |
| 9 | 1.1.1.6 | Executive Summary | 1.5d | 2007-02-26 | 2007-02-27 | 8 | 0d |  | Tyler [50%]; Jane [50%] | 12h | 480 |
| 10 | 1.1.2 | **Budgeting** | 4d | 2007-02-27 | 2007-03-05 |  | 5d |  |  | 5h | 270 |
| 11 | 1.1.2.1 | Direct costs only | 2.5d | 2007-02-27 | 2007-03-01 | 9 | 5d | 0d | Controller [10%] | 2h | 150 |
| 12 | 1.1.2.2 | Project budget | 1.5d | 2007-03-02 | 2007-03-05 | 11 | 5d | 0d | Lori [25%] | 3h | 120 |
| 13 | 1.1.3 | **Cost and Schedule Control** | 3d | 2007-03-05 | 2007-03-08 |  | 5d |  |  | 10h | 500 |
| 14 | 1.1.3.1 | Create project schedule | 2d | 2007-03-05 | 2007-03-07 | 12 | 5d | 0d | Project Manager [50%] | 8h | 400 |
| 15 | 1.1.3.2 | Assign resources to activities | 1d | 2007-03-07 | 2007-03-08 | 14 | 5d |  | Project Manager [25%] | 2h | 100 |
| 16 | 1.1.4 | **Control and Communication** | 14d | 2007-02-27 | 2007-03-19 |  | 0d |  |  | 126h | 5,040 |
| 17 | 1.1.4.1 | Perform risk analysis and write mitigation plan | 2.5d | 2007-02-27 | 2007-03-01 | 9 | 3.5d |  | Jane [25%]; Jen [25%] | 10h | 400 |
| 18 | 1.1.4.2 | Write communication plan | 2d | 2007-02-27 | 2007-03-01 | 9 | 4d |  | Jen [25%]; Houston [25%] | 8h | 320 |
| 19 | 1.1.4.3 | Write scope management plan | 6d | 2007-02-27 | 2007-03-07 | 9 | 0d |  | Tyler [50%]; Lori [50%] | 48h | 1,920 |
| 20 | 1.1.4.4 | Write change management plan | 6d | 2007-03-07 | 2007-03-15 | 17, 18, 19 | 0d |  | Tyler [50%]; Lori [50%] | 48h | 1,920 |
| 21 | 1.1.4.5 | Schedule weekly team and executive meetings | 2d | 2007-03-15 | 2007-03-19 | 15, 20 | 0d |  | Jane [25%]; Houston [25%]; Lori [25%] | 12h | 480 |
| 22 | 1.2 | **Executing the Contract** | 20d | 2007-03-19 | 2007-04-16 |  | 0d |  |  | 198h | 11,200 |
| 23 | 1.2.1 | **Request for Proposal** | 13d | 2007-03-19 | 2007-04-05 |  | 0d |  |  | 106h | 6,100 |
| 24 | 1.2.1.1 | Identify potential vendors | 4d | 2007-03-19 | 2007-03-23 | 21 | 0d |  | Project Manager [25%]; Legal Counsel [25%]; Contract Administrator [25%] | 24h | 1,400 |
| 25 | 1.2.1.2 | Create an RFP | 3d | 2007-03-19 | 2007-03-22 | 21 | 1d |  | Project Manager [50%]; Legal Counsel [25%]; Contract Administrator [25%] | 24h | 1,350 |
| 26 | 1.2.1.3 | Send the RFP to potential vendors | 1d | 2007-03-23 | 2007-03-26 | 24, 25 | 0d |  | Project Manager [25%] | 2h | 100 |
| 27 | 1.2.1.4 | Receive RFP responses | 1d | 2007-03-26 | 2007-03-27 | 26 | 0d |  | Project Manager [25%] | 2h | 100 |
| 28 | 1.2.1.5 | Review all RFP responses | 3d | 2007-03-27 | 2007-03-30 | 27 | 0d |  | Project Manager [25%]; Legal Counsel [25%]; Contract Administrator [25%] | 18h | 1,050 |
| 29 | 1.2.1.6 | Determine final RFP vendors | 2d | 2007-03-30 | 2007-04-03 | 28 | 0d |  | Project Manager [50%]; Legal Counsel [25%]; Contract Administrator [25%] | 16h | 900 |
| 30 | 1.2.1.7 | Finalize the contract | 2d | 2007-04-03 | 2007-04-05 | 29 | 0d |  | Project Manager [25%]; Legal Counsel [50%]; Contract Administrator [50%] | 20h | 1,200 |

| ID | WBS | Task | Duration | Start | Finish | Predecessors | Total slack | Free slack | Resources | Work | Cost |
| --- | --- | --- | --- | --- | --- | --- | --- | --- | --- | --- | --- |
| 31 | 1.2.2 | **Vendor Selection** | 9d | 2007-03-27 | 2007-04-09 |  | 0d |  |  | 32h | 1,800 |
| 32 | 1.2.2.1 | Review RFP responses with the project team | 3d | 2007-03-27 | 2007-03-30 | 27 | 4d |  | Project Manager [50%]; Legal Counsel [25%]; Contract Administrator [25%] | 24h | 1,350 |
| 33 | 1.2.2.2 | Select a vendor based on RFP responses | 1d | 2007-04-05 | 2007-04-06 | 30, 32 | 0d |  | Project Manager [25%]; Legal Counsel [25%]; Contract Administrator [25%] | 6h | 350 |
| 34 | 1.2.2.3 | Notify the selected vendor | 1d | 2007-04-06 | 2007-04-09 | 33 | 0d |  | Project Manager [25%] | 2h | 100 |
| 35 | 1.2.3 | **Contract Award** | 20d | 2007-03-19 | 2007-04-16 |  | 0d |  |  | 60h | 3,300 |
| 36 | 1.2.3.1 | Create a contract | 3d | 2007-03-19 | 2007-03-22 | 21 | 12d |  | Project Manager [25%]; Legal Counsel [50%]; Contract Administrator [50%] | 30h | 1,800 |
| 37 | 1.2.3.2 | Send contract to vendor for review | 1d | 2007-04-09 | 2007-04-10 | 34, 36 | 0d |  | Project Manager [25%]; Contract Administrator [25%] | 4h | 200 |
| 38 | 1.2.3.3 | Obtain contract revision from vendor | 1d | 2007-04-10 | 2007-04-11 | 37 | 0d |  | Project Manager [25%] | 2h | 100 |
| 39 | 1.2.3.4 | Make agreed upon revision to the contract | 2d | 2007-04-11 | 2007-04-13 | 38 | 0d |  | Project Manager [50%]; Contract Administrator [75%] | 20h | 1,000 |
| 40 | 1.2.3.5 | Sign contract | 1d | 2007-04-13 | 2007-04-16 | 39 | 0d |  | Project Manager [25%]; Contract Administrator [25%] | 4h | 200 |
| 41 | 1.3 | **Project Specifications** | 9d | 2007-04-16 | 2007-04-27 |  | 0d |  |  | 226h | 7,530 |
| 42 | 1.3.1 | **Project Requirement** | 8d | 2007-04-16 | 2007-04-26 |  | 1d |  |  | 58h | 2,060 |
| 43 | 1.3.1.1 | Identify project requirements | 5d | 2007-04-16 | 2007-04-23 | 40 | 1d | 0d | Sales [50%]; DesignTeam [50%] | 40h | 1,400 |
| 44 | 1.3.1.2 | Document project requirements | 2d | 2007-04-23 | 2007-04-25 | 43 | 1d | 0d | Sales [25%]; DesignTeam [25%] | 8h | 280 |
| 45 | 1.3.1.3 | Document continuing technical support plan by vendor | 2d | 2007-04-23 | 2007-04-25 | 43 | 1d | 0d | Sales [25%]; DesignTeam [25%] | 8h | 280 |
| 46 | 1.3.1.4 | Provide project requirements to vendor | 1d | 2007-04-25 | 2007-04-26 | 44, 45 | 1d |  | Project Manager [25%] | 2h | 100 |
| 47 | 1.3.2 | **Security Requirements** | 5d | 2007-04-16 | 2007-04-23 |  | 4d |  |  | 24h | 730 |
| 48 | 1.3.2.1 | Identify security requirements | 3d | 2007-04-16 | 2007-04-19 | 40 | 4d | 0d | Engineering [50%]; IT Group [25%] | 18h | 510 |
| 49 | 1.3.2.2 | Document security requirements | 1d | 2007-04-19 | 2007-04-20 | 48 | 4d | 0d | Engineering [25%]; IT Group [25%] | 4h | 120 |
| 50 | 1.3.2.3 | Provide security requirements to vendor | 1d | 2007-04-20 | 2007-04-23 | 49 | 4d |  | Project Manager [25%] | 2h | 100 |
| 51 | 1.3.3 | **Performance Requirments** | 7d | 2007-04-16 | 2007-04-25 |  | 2d |  |  | 58h | 1,700 |
| 52 | 1.3.3.1 | Identify performance requirements | 4d | 2007-04-16 | 2007-04-20 | 40 | 2d | 0d | Engineering [50%]; IT Group [25%] | 24h | 680 |
| 53 | 1.3.3.2 | Identify average, maximum, minimum performance thresholds | 4d | 2007-04-16 | 2007-04-20 | 40 | 2d | 0d | Engineering [50%]; IT Group [25%] | 24h | 680 |
| 54 | 1.3.3.3 | Document performance requirements | 2d | 2007-04-20 | 2007-04-24 | 52, 53 | 2d | 0d | Engineering [25%]; IT Group [25%] | 8h | 240 |
| 55 | 1.3.3.4 | Provide performance requirements to vendor | 1d | 2007-04-24 | 2007-04-25 | 54 | 2d |  | Project Manager [25%] | 2h | 100 |

| ID | WBS | Task | Type | Duration | Start | Finish | Predecessors | Total slack | Free slack | Resources | Work | Cost |
| --- | --- | --- | --- | --- | --- | --- | --- | --- | --- | --- | --- | --- |
| 56 | 1.3.4 | **Website Design** |  | 9d | 2007-04-16 | 2007-04-27 |  | 0d |  |  | 86h | 3,040 |
| 57 | 1.3.4.1 | Gather idea for the website design |  | 5d | 2007-04-16 | 2007-04-23 | 40 | 0d |  | DesignTeam [50%]; IT Group [50%] | 40h | 1,400 |
| 58 | 1.3.4.2 | Analyze competitor websites |  | 4d | 2007-04-16 | 2007-04-20 | 40 | 1d |  | DesignTeam [50%]; IT Group [50%] | 32h | 1,120 |
| 59 | 1.3.4.3 | Document website design preferences |  | 3d | 2007-04-23 | 2007-04-26 | 57, 58 | 0d |  | DesignTeam [25%]; IT Group [25%] | 12h | 420 |
| 60 | 1.3.4.4 | Inform vendor of the desired design |  | 1d | 2007-04-26 | 2007-04-27 | 59 | 0d |  | Project Manager [25%] | 2h | 100 |
| 61 | 1.3.5 | Project Specifications Complete | milestone | 0d | 2007-04-27 | 2007-04-27 | 46, 50, 55, 60 | 0d |  |  |  |  |
| 62 | 1.4 | **Vendor Website Development** |  | 24d | 2007-04-27 | 2007-05-31 |  | 0d |  |  | 680h | 65,760 |
| 63 | 1.4.1 | **Development** |  | 19d | 2007-04-27 | 2007-05-24 |  | 0d |  |  | 568h | 56,800 |
| 64 | 1.4.1.1 | Code UI |  | 5d | 2007-04-27 | 2007-05-04 | 61 | 9d |  | Vendor Developers | 40h | 4,000 |
| 65 | 1.4.1.2 | Create tables |  | 5d | 2007-04-27 | 2007-05-04 | 61 | 0d |  | Vendor Developers [300%] | 120h | 12,000 |
| 66 | 1.4.1.3 | Map fields to tables |  | 5d | 2007-05-04 | 2007-05-11 | 65 | 0d |  | Vendor Developers [300%] | 120h | 12,000 |
| 67 | 1.4.1.4 | Build databases |  | 4d | 2007-05-11 | 2007-05-17 | 66 | 0d |  | Vendor Developers [400%] | 128h | 12,800 |
| 68 | 1.4.1.5 | Build webservices |  | 5d | 2007-05-17 | 2007-05-24 | 64, 67 | 0d |  | Vendor Developers [400%] | 160h | 16,000 |
| 69 | 1.4.2 | **Unit Testing** |  | 24d | 2007-04-27 | 2007-05-31 |  | 0d |  |  | 112h | 8,960 |
| 70 | 1.4.2.1 | Write unit test plan |  | 2d | 2007-04-27 | 2007-05-01 | 61 | 15d | 0d | Vendor Testers | 16h | 1,280 |
| 71 | 1.4.2.2 | Write unit test cases |  | 2d | 2007-05-01 | 2007-05-03 | 70 | 15d |  | Vendor Testers | 16h | 1,280 |
| 72 | 1.4.2.3 | Unit test the website |  | 5d | 2007-05-24 | 2007-05-31 | 68, 71 | 0d |  | Vendor Testers [200%] | 80h | 6,400 |
| 73 | 1.5 | **User Testing** |  | 40d | 2007-04-27 | 2007-06-22 |  | 2d |  |  | 204h | 11,510 |
| 74 | 1.5.1 | **Preliminary Tests** |  | 26d | 2007-04-27 | 2007-06-04 |  | 0d |  |  | 50h | 1,800 |
| 75 | 1.5.1.1 | Create a user acceptance testing group |  | 3d | 2007-04-27 | 2007-05-02 | 61 | 20d | 0d | Project Manager [75%] | 18h | 900 |
| 76 | 1.5.1.2 | Create a test plan |  | 1d | 2007-05-02 | 2007-05-03 | 75 | 20d | 0d | Testing Group [50%] | 4h | 100 |
| 77 | 1.5.1.3 | Create test scripts |  | 1d | 2007-05-03 | 2007-05-04 | 76 | 20d |  | Testing Group | 8h | 200 |
| 78 | 1.5.1.4 | Create test result reports |  | 1d | 2007-05-03 | 2007-05-04 | 76 | 20d |  | Testing Group | 8h | 200 |
| 79 | 1.5.1.5 | Obtain the test site URL from vendor |  | 1d | 2007-05-31 | 2007-06-01 | 72 | 0d |  | Project Manager [50%] | 4h | 200 |
| 80 | 1.5.1.6 | Begin user acceptance testing |  | 1d | 2007-06-01 | 2007-06-04 | 77, 78, 79 | 0d |  | Testing Group | 8h | 200 |

| ID | WBS | Task | Type | Duration | Start | Finish | Predecessors | Total slack | Free slack | Deadline | Resources | Work | Cost |
| --- | --- | --- | --- | --- | --- | --- | --- | --- | --- | --- | --- | --- | --- |
| 81 | 1.5.2 | **Feed back** |  | 7d | 2007-06-04 | 2007-06-13 |  | 0d |  |  |  | 44h | 1,540 |
| 82 | 1.5.2.1 | Gather feedback from the user acceptance group |  | 1d | 2007-06-04 | 2007-06-05 | 80 | 0d |  |  | Analyst | 8h | 280 |
| 83 | 1.5.2.2 | Review feedback with the project team |  | 3d | 2007-06-05 | 2007-06-08 | 82 | 0d |  |  | Analyst [50%] | 12h | 420 |
| 84 | 1.5.2.3 | Review feedback with the vendor |  | 2d | 2007-06-05 | 2007-06-07 | 82 | 1d |  |  | Analyst [50%] | 8h | 280 |
| 85 | 1.5.2.4 | Establish changes that need to be incorporated into the website |  | 1d | 2007-06-08 | 2007-06-11 | 83, 84 | 0d |  |  | Analyst | 8h | 280 |
| 86 | 1.5.2.5 | Gather feedback and review until acceptance testing group satisfaction |  | 2d | 2007-06-11 | 2007-06-13 | 85 | 0d |  |  | Analyst [50%] | 8h | 280 |
| 87 | 1.5.3 | **Customer Acceptance** |  | 7d | 2007-06-13 | 2007-06-22 |  | 2d |  |  |  | 110h | 8,170 |
| 88 | 1.5.3.1 | Incorporate feedback into the website |  | 3d | 2007-06-13 | 2007-06-18 | 86 | 2d | 0d |  | Vendor Developers [200%] | 48h | 4,800 |
| 89 | 1.5.3.2 | Test the revised website which incorporate feedback given to the vendor |  | 2d | 2007-06-18 | 2007-06-20 | 88 | 2d | 0d |  | Testing Group; Vendor Testers [200%] | 48h | 2,960 |
| 90 | 1.5.3.3 | Obtain additional feedback from the user acceptance group |  | 1d | 2007-06-20 | 2007-06-21 | 89 | 2d | 0d |  | Analyst [75%] | 6h | 210 |
| 91 | 1.5.3.4 | Sign off on the website |  | 1d | 2007-06-21 | 2007-06-22 | 90 | 2d | 0d |  | Testing Group | 8h | 200 |
| 92 | 1.6 | **Website Launch** |  | 10d | 2007-06-13 | 2007-06-27 |  | 0d |  |  |  | 126h | 4,380 |
| 93 | 1.6.1 | **Marketing and Advertising** |  | 8d | 2007-06-13 | 2007-06-25 |  | 2d |  |  |  | 26h | 780 |
| 94 | 1.6.1.1 | Create a marketing plan |  | 2d | 2007-06-13 | 2007-06-15 | 86 | 5d | 0d |  | Marketing [75%] | 12h | 360 |
| 95 | 1.6.1.2 | Create marketing material |  | 2d | 2007-06-15 | 2007-06-19 | 94 | 5d | 3d |  | Marketing [75%] | 12h | 360 |
| 96 | 1.6.1.3 | Distribute marketing material |  | 1d | 2007-06-22 | 2007-06-25 | 91, 95 | 2d |  |  | Marketing [25%] | 2h | 60 |
| 97 | 1.6.2 | **Training** |  | 5d | 2007-06-13 | 2007-06-20 |  | 5d |  |  |  | 40h | 1,200 |
| 98 | 1.6.2.1 | Create a training plan |  | 2d | 2007-06-13 | 2007-06-15 | 86 | 5d | 0d |  | Training | 16h | 480 |
| 99 | 1.6.2.2 | Create training material |  | 2d | 2007-06-15 | 2007-06-19 | 98 | 5d | 0d |  | Training | 16h | 480 |
| 100 | 1.6.2.3 | Conduct training courses |  | 1d | 2007-06-19 | 2007-06-20 | 99 | 5d |  |  | Training | 8h | 240 |
| 101 | 1.6.3 | **Technical Support** |  | 10d | 2007-06-13 | 2007-06-27 |  | 0d |  |  |  | 60h | 2,400 |
| 102 | 1.6.3.1 | Create a technical support department |  | 5d | 2007-06-13 | 2007-06-20 | 86 | 0d |  |  | Technical Support [75%] | 30h | 1,200 |
| 103 | 1.6.3.2 | Hire technical support representatives |  | 5d | 2007-06-20 | 2007-06-27 | 102 | 0d |  |  | Technical Support [75%] | 30h | 1,200 |
| 104 | 1.7 | **Project Closure** |  | 1d | 2007-06-27 | 2007-06-28 |  | 0d |  |  |  | 8h | 320 |
| 105 | 1.7.1 | Launch Website |  | 1d | 2007-06-27 | 2007-06-28 | 96, 100, 103 | 0d |  |  | Project Manager [50%]; Marketing [50%] | 8h | 320 |
| 106 | 1.7.2 | Close Out project | milestone | 0d | 2007-06-28 | 2007-06-28 | 105 | 0d |  | 2007-06-28 |  |  |  |
